# Project Management Plan

Schedule from MS Project, 2003-07-01 to 2003-09-03.

## Calendars

- Standard: Mon-Fri 08:00-12:00, 13:00-17:00; Sat-Sun off.

## Resources

| Resource | Notes |
| --- | --- |
| Project Director | Responsible for management of the project at a strategic level. |
| Application Architect | Defines the major application systems needed to support the enterprise. During systems development, the Application Architect defines the application solution. |
| Project Manager | Responsible for the delivery of a quality project on-schedule, within budget, with a satisfied Acceptor and a motivated project team. |
| Technical Architect | Defines the technologies and standards required to support the application and information architectures. During systems development, the Technical Architect defines the technical solution. |
| Acceptor | Key individual within the business organization who is the principal interface with the project team and who has the authority to accept all deliverables and resolve all project issues (sometimes referred to as the Project Sponsor). |
| Quality Assurance Manager | Responsible for providing confidence to management that the Quality System is being applied. |
| Team Leader | Responsible to a Project Manager for managing the performance of a specific work team. |
| Contracts Manager | Responsible for managing the contractual interfaces with the customer and with subcontractors. |

## Schedule

| ID | WBS | Task | Duration | Start | Finish | Predecessors | Total slack | Free slack | Resources | Work | Text8 |
| --- | --- | --- | --- | --- | --- | --- | --- | --- | --- | --- | --- |
| 1 | 1 | **Project Management Plan** | 46.5d | 2003-07-01 | 2003-09-03 |  | 0d |  |  | 728h | key:1 |
| 2 | 1.1 | **Initiating** | 2d | 2003-07-01 | 2003-07-02 |  | 14.5d | 0d |  | 24h | key:2 |
| 3 | 1.1.1 | **Project Initiation** | 2d | 2003-07-01 | 2003-07-02 |  | 14.5d |  |  | 24h | key:3 |
| 4 | 1.1.1.1 | Identify goals and objectives | 1d | 2003-07-01 | 2003-07-01 |  | 14.5d | 0d | Project Director | 8h | key:4 |
| 5 | 1.1.1.2 | Document project costs and benefits | 0.5d | 2003-07-02 | 2003-07-02 | 4 | 14.5d | 0d | Application Architect; Project Manager; Technical Architect | 8h | key:5 |
| 6 | 1.1.1.3 | Develop project charter | 0.5d | 2003-07-02 | 2003-07-02 | 5 | 14.5d |  | Project Manager; Acceptor | 8h | key:6 |
| 7 | 1.2 | **Planning** | 21d | 2003-07-03 | 2003-07-31 | 2 | 14.5d | 0d |  | 328h | key:7 |
| 8 | 1.2.1 | **Define Scope** | 6.5d | 2003-07-03 | 2003-07-11 |  | 14.5d | 0d |  | 72h | key:8 |
| 9 | 1.2.1.1 | Develop strategies and plans | 1d | 2003-07-03 | 2003-07-03 |  | 14.5d | 0d | Project Director | 8h | key:9 |
| 10 | 1.2.1.2 | Conduct planning workshop | 1d | 2003-07-04 | 2003-07-04 | 9 | 14.5d | 0d | Project Director | 8h | key:10 |
| 11 | 1.2.1.3 | Research previous experience | 1d | 2003-07-03 | 2003-07-03 |  | 15.5d | 1d | Project Manager | 8h | key:11 |
| 12 | 1.2.1.4 | Define scope | 1d | 2003-07-07 | 2003-07-07 | 10, 11 | 14.5d | 0d | Project Manager | 8h | key:12 |
| 13 | 1.2.1.5 | Develop high-level work breakdown structure | 1d | 2003-07-08 | 2003-07-08 | 12 | 14.5d | 0d | Project Manager | 8h | key:13 |
| 14 | 1.2.1.6 | Build detailed work breakdown structure | 1d | 2003-07-09 | 2003-07-09 | 13 | 14.5d | 0d | Project Manager | 8h | key:14 |
| 15 | 1.2.1.7 | Document project costs and benefits | 0.5d | 2003-07-11 | 2003-07-11 | 14 | 14.5d | 0d | Application Architect; Project Manager; Technical Architect | 8h | key:15 |
| 16 | 1.2.1.8 | Specify deliverables and acceptance criteria | 1d | 2003-07-10 | 2003-07-10 | 14 | 15d | 0d | Project Manager | 8h | key:16 |
| 17 | 1.2.1.9 | Document assumptions | 1d | 2003-07-10 | 2003-07-11 | 12FF, 13FF, 14FF, 15FF, 16FF | 19.5d |  | Project Manager | 8h | key:17 |
| 18 | 1.2.2 | **Document Project Support Plans** | 1.5d | 2003-07-23 | 2003-07-24 | 8 | 21.5d | 2d |  | 32h | key:18 |
| 19 | 1.2.2.1 | Document risk management plan | 0.5d | 2003-07-23 | 2003-07-23 |  | 22.5d |  | Project Manager; Acceptor | 8h | key:19 |
| 20 | 1.2.2.2 | Document configuration management plan | 0.5d | 2003-07-23 | 2003-07-23 |  | 22d |  | Project Manager; Acceptor | 8h | key:20 |
| 21 | 1.2.2.3 | Document data management plan | 0.5d | 2003-07-24 | 2003-07-24 |  | 21.5d |  | Project Manager; Acceptor | 8h | key:21 |
| 22 | 1.2.2.4 | Document communications management plan | 0.5d | 2003-07-24 | 2003-07-24 |  | 21.5d |  | Project Manager; Acceptor | 8h | key:22 |
| 23 | 1.2.3 | **Develop Project Schedule** | 5d | 2003-07-11 | 2003-07-18 | 8 | 19.5d | 0d |  | 40h | key:23 |
| 24 | 1.2.3.1 | Develop resource plans | 1d | 2003-07-11 | 2003-07-14 |  | 19.5d | 0d | Project Manager | 8h | key:24 |
| 25 | 1.2.3.2 | Prepare project estimates | 1d | 2003-07-14 | 2003-07-15 |  | 18.5d | 0d | Project Manager | 8h | key:25 |
| 26 | 1.2.3.3 | Define dependencies and develop project schedule | 1d | 2003-07-15 | 2003-07-16 |  | 17.5d | 0d | Project Manager | 8h | key:26 |
| 27 | 1.2.3.4 | Document assumptions | 1d | 2003-07-16 | 2003-07-17 | 24FF, 25FF, 26FF | 19.5d | 0d | Project Manager | 8h | key:27 |
| 28 | 1.2.3.5 | Conduct peer review | 1d | 2003-07-17 | 2003-07-18 | 24, 27 | 19.5d |  | Project Manager | 8h | key:28 |

Notes:
- 1: A set of methods and techniques designed to ensure successful delivery projects (large complex projects are often managed by a project management office using this methodology) in a cost-effective, schedule-compressed manner.
- 2: The Initiating Stage defines the preliminary analysis of the project objectives and ensures that further project work is authorized.
- 3: The preliminary steps necessary to develop the project's goals and objectives and secure commitment to continue the project.
- 4: Define the primary goals and objectives for the project.
- 5: Perform the cost/benefit analysis for the projects. Document the cash flows, such as benefits minus costs. Document the benefits and risks that cannot be assigned a cash value.
- 6: Develop the project charter and present it for approval to proceed with the project.
- 7: The Planning Stage defines the necessary steps to ensure that proper planning is done during project start-up, before each new phase starts, and as part of the change management process.
- 8: Establish the project scope, work breakdown structure, and deliverables necessary to ensure that the objectives defined in the project charter are met.
- 9: Understand the business organization and its personnel and formulate high-level strategies and plans to ensure achievement of objectives.
- 10: Conduct an internal planning session to evaluate all elements of the project, identify the critical success factors, and map out the project approach.
- 11: Research previous experience with similar projects, and with similar technologies, and obtain sample materials.
- 12: Establish and maintain a common understanding with the customer of the scope of the project.
- 13: Identify all of the work to be performed and organize the work into manageable pieces (subprojects).
- 14: Model the project in terms of detailed phases, activities, tasks, deliverables, and resources.
- 15: Perform the cost/benefit analysis for the projects. Document the cash flows, such as benefits minus costs. Document the benefits and risks that cannot be assigned a cash value.
- 16: Create a clear and unambiguous definition of each deliverable in terms of format, size, and quality requirements, and specify the acceptance procedures and acceptance criteria for each deliverable.
- 17: Maintain an ongoing list of the assumptions on which the estimates and schedules are based.
- 18: Document the risk, configuration, and data management plans that will be used to define these aspects of the project delivery approach.
- 19: Describe the methods and procedures to be used to identify, evaluate, and eliminate or minimize project risks.
- 20: Describe the methods and procedures to be used to establish effective identification, control, accounting, and auditing of controlled items throughout the development life cycle.
- 21: Describe the methods and procedures to be used to implement and maintain a data management system for the identification, acquisition, distribution, delivery, and status reporting of data.
- 22: Describe the methods and procedures to be used to identify and document the project communications requirements.
- 23: Identify and assign project resources, determine project activity and task dependencies, develop task estimates, and develop the project schedule.
- 24: Identify resources (human and other) that will be required to successfully deliver the project.
- 25: Produce a detailed estimate of the costs and material resources required to deliver each component of the work breakdown structure.
- 26: Define the milestones and phase dates for each component of the work breakdown structure, and identify the dependencies between the work components (the network logic).
- 27: Maintain an ongoing list of the assumptions on which the estimates and schedules are based.
- 28: Conduct a peer review session to solicit feedback on the project approach from senior delivery and management personnel from outside the project team.

| ID | WBS | Task | Duration | Start | Finish | Predecessors | Total slack | Free slack | Resources | Work | Text8 |
| --- | --- | --- | --- | --- | --- | --- | --- | --- | --- | --- | --- |
| 29 | 1.2.4 | **Develop Financial Plan** | 2d | 2003-07-23 | 2003-07-25 | 23 | 20.5d | 1d |  | 16h | key:29 |
| 30 | 1.2.4.1 | Prepare financial plan | 1d | 2003-07-23 | 2003-07-24 |  | 20.5d | 0d | Project Director | 8h | key:30 |
| 31 | 1.2.4.2 | Set up standards and procedures for cost and schedule management | 1d | 2003-07-24 | 2003-07-25 | 30 | 20.5d |  | Project Director | 8h | key:31 |
| 32 | 1.2.5 | **Plan for Quality** | 2.5d | 2003-07-11 | 2003-07-15 | 8 | 28d | 8.5d |  | 24h | key:32 |
| 33 | 1.2.5.1 | Define quality requirements | 1d | 2003-07-11 | 2003-07-14 |  | 28d | 0d | Quality Assurance Manager | 8h | key:33 |
| 34 | 1.2.5.2 | Set up standards and procedures for quality management | 1d | 2003-07-14 | 2003-07-15 | 33 | 28d | 0d | Quality Assurance Manager | 8h | key:34 |
| 35 | 1.2.5.3 | Document quality management plan | 0.5d | 2003-07-15 | 2003-07-15 | 34 | 28d |  | Quality Assurance Manager; Acceptor | 8h | key:35 |
| 36 | 1.2.6 | **Develop Risk Plans** | 2.5d | 2003-07-18 | 2003-07-22 | 8 | 23d | 3.5d |  | 24h | key:36 |
| 37 | 1.2.6.1 | Identify risks | 1d | 2003-07-18 | 2003-07-21 |  | 23d | 0d | Project Manager | 8h | key:37 |
| 38 | 1.2.6.2 | Analyze risks | 1d | 2003-07-21 | 2003-07-22 | 37 | 23d | 0d | Project Manager | 8h | key:38 |
| 39 | 1.2.6.3 | Document risks | 0.5d | 2003-07-22 | 2003-07-22 | 38 | 23d |  | Project Manager; Acceptor | 8h | key:39 |
| 40 | 1.2.7 | **Organize Project Resources** | 6d | 2003-07-18 | 2003-07-28 | 23 | 19.5d | 0d |  | 40h | key:40 |
| 41 | 1.2.7.1 | Develop organization structure | 1d | 2003-07-18 | 2003-07-21 |  | 19.5d | 0d | Project Director | 8h | key:41 |
| 42 | 1.2.7.2 | Develop staffing plan | 1d | 2003-07-21 | 2003-07-22 | 41 | 19.5d | 0d | Project Director | 8h | key:42 |
| 43 | 1.2.7.3 | Obtain resources | 1d | 2003-07-22 | 2003-07-23 | 42 | 19.5d | 0d | Project Director | 8h | key:43 |
| 44 | 1.2.7.4 | Conduct team orientation | 1d | 2003-07-25 | 2003-07-28 | 43 | 19.5d |  | Project Director | 8h | key:44 |
| 45 | 1.2.7.5 | Set up standards and procedures for team performance | 1d | 2003-07-18 | 2003-07-21 |  | 24.5d |  | Team Leader | 8h | key:45 |
| 46 | 1.2.8 | **Develop Procurement Plans** | 4.5d | 2003-07-11 | 2003-07-17 | 8 | 26d | 6.5d |  | 40h | key:46 |
| 47 | 1.2.8.1 | Determine procurement requirements | 1d | 2003-07-11 | 2003-07-14 |  | 26d | 0d | Contracts Manager | 8h | key:47 |
| 48 | 1.2.8.2 | Define subcontractor scope | 1d | 2003-07-14 | 2003-07-15 | 47 | 26d | 0d | Contracts Manager | 8h | key:48 |
| 49 | 1.2.8.3 | Identify potential subcontractors | 1d | 2003-07-15 | 2003-07-16 | 48 | 26d | 0d | Contracts Manager | 8h | key:49 |
| 50 | 1.2.8.4 | Identify subcontract type | 1d | 2003-07-16 | 2003-07-17 | 49 | 26d | 0d | Contracts Manager | 8h | key:50 |
| 51 | 1.2.8.5 | Document subcontractor management plan | 0.5d | 2003-07-17 | 2003-07-17 | 50 | 26d |  | Contracts Manager; Acceptor | 8h | key:51 |
| 52 | 1.2.9 | **Set Up Project Environment** | 3.5d | 2003-07-28 | 2003-07-31 | 8, 18, 23, 29, 32, 36, 40, 46 | 17d |  |  | 40h | key:52 |
| 53 | 1.2.9.1 | Prepare facilities | 1d | 2003-07-28 | 2003-07-29 |  | 19.5d |  | Project Manager | 8h | key:53 |
| 54 | 1.2.9.2 | Set up project standards and procedures | 1d | 2003-07-28 | 2003-07-29 |  | 19.5d |  | Quality Assurance Manager | 8h | key:54 |
| 55 | 1.2.9.3 | Set up project management tools | 1d | 2003-07-29 | 2003-07-30 |  | 18.5d |  | Project Manager | 8h | key:55 |
| 56 | 1.2.9.4 | Set up project book | 1d | 2003-07-30 | 2003-07-31 |  | 17.5d |  | Project Manager | 8h | key:56 |
| 57 | 1.2.9.5 | Document project management plan | 0.5d | 2003-07-31 | 2003-07-31 |  | 17d |  | Project Manager; Acceptor | 8h | key:57 |

Notes:
- 29: Document the expected cash flow as the basis for monitoring the monthly financial performance of the project.
- 30: Translate the estimates and schedule into an expected monthly cash flow as the basis for monitoring the project's financial performance.
- 31: Define and document the specific standards and procedures for monitoring and controlling the project costs, schedule, and performance.
- 32: Prepare the way for a quality project.
- 33: Define the expectations for quality, the internal process and product attributes that indicate whether the quality factors are being achieved, and the measures to be used to give visibility to the levels of quality being achieved.
- 34: Define and document the specific standards and procedures for quality management activities.
- 35: Establish the baseline against which project quality will be measured and describe the methods and procedures to be used for monitoring and verifying project quality.
- 36: Identify, analyze, and profile project risks.
- 37: Risk identification identifies the risks, which, if unmanaged, could impact the project.
- 38: Qualitative and quantitative analysis of a project's risks and impacts. The result is a prioritized list of risks.
- 39: Profile the potential risks to the project by producing specific plans to reduce or eliminate high-risk items before they become obstacles to successful project delivery.
- 40: Identify and mobilize a productive and motivated project team.
- 41: Create an effective and efficient project organization structure.
- 42: Identify the skills required for each role within the project structure, the person per day estimates, and start and end dates for each role.
- 43: Negotiate for resources and prepare action plans to identify any staffing deficiencies.
- 44: Provide a formal orientation to the project and build a common understanding within the team.
- 45: Define and document the specific standards and procedures for the general conduct of the project team.
- 46: Understand and document what needs to be purchased or contracted for the project and how the purchasing or contracting is to be done.
- 47: Understand which project components will be delivered with in-house resources and which will have to be procured from outside vendors or suppliers
- 48: Define the scope of work to be accomplished by each project subcontractor.
- 49: Develop and qualify a shortlist of potential subcontractors for the project.
- 50: Identify the appropriate type of contract to be used for each identified procurement requirement.
- 51: Describe the methods and procedures to be used in subcontracting work.
- 52: Ensure that the fundamental project delivery infrastructure is in place, such as work space, standards and procedures, and project tools.
- 53: Obtain and furnish work space with the appropriate facilities.
- 54: Define and document the specific standards and procedures to ensure consistent delivery in accordance with the quality requirements.
- 55: Implement the project management tools that the project team will use to manage performance.
- 56: Collect and store the project's quality and scope control records in a standard, single location to provide familiar, rapid access to key project management information.
- 57: Establish the baseline for scope, budget, schedule, and quality against which project performance is measured and all changes to the project are controlled.

| ID | WBS | Task | Duration | Start | Finish | Predecessors | Total slack | Resources | Work | Text8 |
| --- | --- | --- | --- | --- | --- | --- | --- | --- | --- | --- |
| 58 | 1.3 | **Executing** | 10d | 2003-08-01 | 2003-08-14 | 7 | 8d |  | 208h | key:58 |
| 59 | 1.3.1 | **Manage Project Data** | 7d | 2003-08-01 | 2003-08-11 |  | 11d |  | 64h | key:59 |
| 60 | 1.3.1.1 | Authorize work | 1d | 2003-08-01 | 2003-08-01 |  | 17d | Team Leader | 8h | key:60 |
| 61 | 1.3.1.2 | Manage action items | 1d | 2003-08-01 | 2003-08-01 |  | 17d | Project Manager | 8h | key:61 |
| 62 | 1.3.1.3 | Manage project records | 1d | 2003-08-04 | 2003-08-04 |  | 16d | Project Manager | 8h | key:62 |
| 63 | 1.3.1.4 | Manage data items | 1d | 2003-08-05 | 2003-08-05 |  | 15d | Project Manager | 8h | key:63 |
| 64 | 1.3.1.5 | Manage configuration items | 1d | 2003-08-06 | 2003-08-06 |  | 14d | Project Manager | 8h | key:64 |
| 65 | 1.3.1.6 | Manage process data | 1d | 2003-08-07 | 2003-08-07 |  | 13d | Project Manager | 8h | key:65 |
| 66 | 1.3.1.7 | Provide general office support | 1d | 2003-08-08 | 2003-08-08 |  | 12d | Project Manager | 8h | key:66 |
| 67 | 1.3.1.8 | Administer project security processes | 1d | 2003-08-11 | 2003-08-11 |  | 11d | Project Manager | 8h | key:67 |
| 68 | 1.3.2 | **Manage Project Communication** | 3d | 2003-08-01 | 2003-08-05 |  | 15d |  | 24h | key:68 |
| 69 | 1.3.2.1 | Review progress | 1d | 2003-08-01 | 2003-08-01 |  | 17d | Project Director | 8h | key:69 |
| 70 | 1.3.2.2 | Resolve issues | 1d | 2003-08-04 | 2003-08-04 |  | 16d | Project Director | 8h | key:70 |
| 71 | 1.3.2.3 | Monitor satisfaction | 1d | 2003-08-05 | 2003-08-05 |  | 15d | Project Director | 8h | key:71 |
| 72 | 1.3.3 | **Manage Team Performance** | 9d | 2003-08-04 | 2003-08-14 |  | 8d |  | 56h | key:72 |
| 73 | 1.3.3.1 | Assign responsibilities | 1d | 2003-08-04 | 2003-08-04 |  | 16d | Team Leader | 8h | key:73 |
| 74 | 1.3.3.2 | Meet with team | 1d | 2003-08-05 | 2003-08-05 |  | 15d | Team Leader | 8h | key:74 |
| 75 | 1.3.3.3 | Manage team communications | 1d | 2003-08-12 | 2003-08-12 |  | 10d | Project Manager | 8h | key:75 |
| 76 | 1.3.3.4 | Recognize success | 1d | 2003-08-06 | 2003-08-06 |  | 14d | Project Director | 8h | key:76 |
| 77 | 1.3.3.5 | Monitor team morale | 1d | 2003-08-13 | 2003-08-13 |  | 9d | Project Manager | 8h | key:77 |
| 78 | 1.3.3.6 | Conduct team performance reviews | 1d | 2003-08-06 | 2003-08-06 |  | 14d | Team Leader | 8h | key:78 |
| 79 | 1.3.3.7 | Provide team training | 1d | 2003-08-14 | 2003-08-14 |  | 8d | Project Manager | 8h | key:79 |
| 80 | 1.3.4 | **Assure Quality** | 4d | 2003-08-01 | 2003-08-06 |  | 14d |  | 32h | key:80 |
| 81 | 1.3.4.1 | Participate in walk-throughs and reviews | 1d | 2003-08-01 | 2003-08-01 |  | 17d | Quality Assurance Manager | 8h | key:81 |
| 82 | 1.3.4.2 | Conduct inspections and audits | 1d | 2003-08-04 | 2003-08-04 |  | 16d | Quality Assurance Manager | 8h | key:82 |
| 83 | 1.3.4.3 | Participate in testing | 1d | 2003-08-05 | 2003-08-05 |  | 15d | Quality Assurance Manager | 8h | key:83 |
| 84 | 1.3.4.4 | Conduct project reviews | 1d | 2003-08-06 | 2003-08-06 |  | 14d | Quality Assurance Manager | 8h | key:84 |

Notes:
- 58: Coordinating the people and other resources required to deliver the project
- 59: Manage the data that supports the project and implement the discipline of configuration management.
- 60: Delegate delivery responsibilities for a work package, establish a clear and unambiguous understanding for how the work package is to be delivered, observe commitment, and formally authorize the commencement of work.
- 61: Record, communicate, and ensure closure on all action items, including changes to the contractual baseline, requirements for information, problem reports, and service requests, to facilitate effective decision-making within acceptable time frames.
- 62: Establish, maintain, and dispose of project records in a way that provides adequate access for team members during the project and long-term retention for use in subsequent projects.
- 63: Identify, control, and report upon the scheduling, publishing and release of all formal data items, and the replacement of obsolete versions, in accordance with the terms of the project plan.
- 64: Identify, control, and report on selected baseline items, such as the project description, product specifications, and process specifications, which formally define the project.
- 65: Collect and maintain a standard set of data on the project's processes, metrics, and lessons learned.
- 66: Provide general office support such as producing correspondence, document production and distribution services, and maintaining files and logs.
- 67: Design and implement procedures to ensure adequate project security, including such things as badges, sign-in registers, electronic lock accessibility, and monitoring the security-related practices in all project facilities.
- 68: Develop and maintain a good working relationship with all the project stakeholders by using effective project communications.
- 69: Maintain frequent formal and informal contact with project stakeholders to review progress and maintain open communication.
- 70: Identify, track, and resolve issues affecting the project.
- 71: Monitor how well the stakeholder's expectations for quality service delivery are being met.
- 72: Optimize the performance of team members in achieving project goals.
- 73: Delegate responsibility for work assignments and observe commitment.
- 74: Meet regularly with team members to review status, share experiences, provide suggestions, and resolve problems and concerns.
- 75: Develop and implement effective communications among all members of the project team.
- 76: Develop and implement means to recognize and reward quality service, creativity, innovation, and success.
- 77: Monitor team morale and take action to correct problem areas.
- 78: Record and communicate the accomplishments of team members, and appraise their skills to facilitate career development.
- 79: Provide training to members of the project team (including business and subcontractor personnel) in the project-specific methodology, tools, or technology, as required.
- 80: Monitor the levels of quality being achieved.
- 81: Participate in structured walk-throughs and reviews of project deliverables with members of the project team to represent quality concerns.
- 82: Conduct inspections and audits to determine the completeness and consistency of processes and deliverables.
- 83: Observe testing, conduct verification testing, and conduct acceptance testing of subcontracted components.
- 84: Review and appraise the project to assess and increase the probability of project success.

| ID | WBS | Task | Duration | Start | Finish | Predecessors | Total slack | Resources | Work | Text8 |
| --- | --- | --- | --- | --- | --- | --- | --- | --- | --- | --- |
| 85 | 1.3.5 | **Contracting with Subcontractors** | 4d | 2003-08-01 | 2003-08-06 |  | 14d |  | 32h | key:85 |
| 86 | 1.3.5.1 | Issue requisition documents | 1d | 2003-08-01 | 2003-08-01 |  | 17d | Contracts Manager | 8h | key:86 |
| 87 | 1.3.5.2 | Evaluate responses | 1d | 2003-08-04 | 2003-08-04 |  | 16d | Contracts Manager | 8h | key:87 |
| 88 | 1.3.5.3 | Negotiate subcontractor contract | 1d | 2003-08-05 | 2003-08-05 |  | 15d | Contracts Manager | 8h | key:88 |
| 89 | 1.3.5.4 | Manage subcontractor contract | 1d | 2003-08-06 | 2003-08-06 |  | 14d | Contracts Manager | 8h | key:89 |
| 90 | 1.4 | **Controlling** | 14d | 2003-08-07 | 2003-08-26 | 7 | 0d |  | 120h | key:90 |
| 91 | 1.4.1 | **Manage Scope and Requirements** | 4d | 2003-08-15 | 2003-08-20 |  | 4d |  | 32h | key:91 |
| 92 | 1.4.1.1 | Manage scope | 1d | 2003-08-15 | 2003-08-15 |  | 7d | Project Manager | 8h | key:92 |
| 93 | 1.4.1.2 | Manage requirements | 1d | 2003-08-18 | 2003-08-18 |  | 6d | Project Manager | 8h | key:93 |
| 94 | 1.4.1.3 | Control decisions | 1d | 2003-08-19 | 2003-08-19 |  | 5d | Project Manager | 8h | key:94 |
| 95 | 1.4.1.4 | Control changes | 1d | 2003-08-20 | 2003-08-20 |  | 4d | Project Manager | 8h | key:95 |
| 96 | 1.4.2 | **Control Schedule** | 3.5d | 2003-08-21 | 2003-08-26 |  | 0.5d |  | 16h | key:96 |
| 97 | 1.4.2.1 | Track status | 0.5d | 2003-08-26 | 2003-08-26 |  | 0.5d | Team Leader; Project Manager | 8h | key:97 |
| 98 | 1.4.2.2 | Maintain work plans | 1d | 2003-08-21 | 2003-08-21 |  | 3d | Project Manager | 8h | key:98 |
| 99 | 1.4.3 | **Manage Risks** | 1d | 2003-08-22 | 2003-08-22 |  | 2d |  | 8h | key:99 |
| 100 | 1.4.3.1 | Manage risks | 1d | 2003-08-22 | 2003-08-22 |  | 2d | Project Manager | 8h | key:100 |
| 101 | 1.4.4 | **Manage Finances** | 13d | 2003-08-07 | 2003-08-25 |  | 1d |  | 24h | key:101 |
| 102 | 1.4.4.1 | Monitor cost and schedule variance | 1d | 2003-08-25 | 2003-08-25 |  | 1d | Project Manager | 8h | key:102 |
| 103 | 1.4.4.2 | Control costs | 1d | 2003-08-07 | 2003-08-07 |  | 13d | Project Director | 8h | key:103 |
| 104 | 1.4.4.3 | Maintain financial plan | 1d | 2003-08-08 | 2003-08-08 |  | 12d | Project Director | 8h | key:104 |
| 105 | 1.4.5 | **Control Quality** | 3d | 2003-08-07 | 2003-08-11 |  | 11d |  | 24h | key:105 |
| 106 | 1.4.5.1 | Control quality | 1d | 2003-08-07 | 2003-08-07 |  | 13d | Quality Assurance Manager | 8h | key:106 |
| 107 | 1.4.5.2 | Measure quality levels | 1d | 2003-08-08 | 2003-08-08 |  | 12d | Quality Assurance Manager | 8h | key:107 |
| 108 | 1.4.5.3 | Facilitate continuous improvement | 1d | 2003-08-11 | 2003-08-11 |  | 11d | Quality Assurance Manager | 8h | key:108 |

Notes:
- 85: Selection and management of any subcontractors required to deliver the project.
- 86: Issue the formal requisition documents to prospective subcontractors.
- 87: Evaluate responses to the formal requisition documents from prospective subcontractors.
- 88: Negotiate effective contracts with subcontractors and arrange subcontract signing.
- 89: Manage the relationship between the acquisition organization and the subcontracting organization.
- 90: Monitoring and measuring the project performance to ensure that the project is on target (on time, on budget, and meeting expectations).
- 91: Maintain a comprehensive, clear, and measurable definition of the project scope and requirements.
- 92: Establish and maintain a common understanding with the acceptor of the scope of the project.
- 93: Establish and maintain a common understanding with the customer of the requirements that will be addressed by the project.
- 94: Ensure that the project team is provided with the information and decisions necessary to keep the project on track.
- 95: Record and obtain approval for any and every change to the approved project baselines.
- 96: Maintain the project schedule to ensure it remains up-to-date, based on approved change requests and revised completion estimates from project team members.
- 97: Track detailed progress against each activity and task, re-assess personnel commitment, and re-forecast the remaining effort to completion and the expected completion date on a regular weekly basis.
- 98: Maintain a current and reliable version of the project work plans, based on approved changes and current estimates to completion.
- 99: Managing the risk log and acting on risk management action plans as required to ensure the project stays on schedule.
- 100: Manage the risk log and the risk action plans to ensure that risks do not impact the project.
- 101: Manage the monthly cash flow of the project, including the forecasted estimates to complete for the remainder of the project.
- 102: Analyze cost and schedule variances from plan and implement corrective action.
- 103: Control project costs and expenses so as deliver the project on budget.
- 104: Reconcile the project's financial data with the corporate financial system and update the financial estimates to complete for the remainder of the project
- 105: Implement and manage a program to ensure the project quality and implement continual improvement of work operations.
- 106: Measure and ensure that the project meets defined quality standards.
- 107: Interpret project measurements as the basis for the continual improvement and optimization of work processes.
- 108: Investigate the causes of problems and analyze work operations to identify process improvements and reduce or eliminate failures.

| ID | WBS | Task | Duration | Start | Finish | Predecessors | Total slack | Resources | Work | Text8 |
| --- | --- | --- | --- | --- | --- | --- | --- | --- | --- | --- |
| 109 | 1.4.6 | **Produce Performance Reports** | 14d | 2003-08-07 | 2003-08-26 |  | 0d |  | 16h | key:109 |
| 110 | 1.4.6.1 | Report weekly status | 0.5d | 2003-08-07 | 2003-08-07 |  | 13.5d | Team Leader; Acceptor | 8h | key:110 |
| 111 | 1.4.6.2 | Report monthly status | 0.5d | 2003-08-26 | 2003-08-26 |  | 0d | Project Manager; Acceptor | 8h | key:111 |
| 112 | 1.5 | **Closing** | 5.5d | 2003-08-27 | 2003-09-03 | 58, 90 | 0d |  | 48h | key:112 |
| 113 | 1.5.1 | **Manage Project Close** | 5.5d | 2003-08-27 | 2003-09-03 |  | 0d |  | 48h | key:113 |
| 114 | 1.5.1.1 | Manage project acceptance | 0.5d | 2003-08-27 | 2003-08-27 |  | 0d | Project Manager; Acceptor | 8h | key:114 |
| 115 | 1.5.1.2 | Assess satisfaction | 1d | 2003-08-27 | 2003-08-28 | 114 | 3d | Project Manager | 8h | key:115 |
| 116 | 1.5.1.3 | Summarize project results and lessons learned | 1d | 2003-08-28 | 2003-08-29 | 114 | 2d | Project Manager | 8h | key:116 |
| 117 | 1.5.1.4 | Review and recognize team performance | 1d | 2003-08-29 | 2003-09-01 | 114 | 1d | Project Manager | 8h | key:117 |
| 118 | 1.5.1.5 | Review and reconcile financial performance | 1d | 2003-09-01 | 2003-09-02 | 114 | 0d | Project Manager | 8h | key:118 |
| 119 | 1.5.1.6 | Close the project records | 1d | 2003-09-02 | 2003-09-03 | 114, 115, 116, 117, 118 | 0d | Project Manager | 8h | key:119 |

Notes:
- 109: Monitor and report on the costs, schedule, and technical performance of the project.
- 110: Summarize and communicate the accomplishments for the reporting period, the objectives for the coming period, problems (if any), the status of outstanding risk items, and suggestions for dealing with issues and problems.
- 111: Keep project status visible to project stakeholders by providing an appropriate summary of project status on a regular monthly basis.
- 112: Close the project upon completion.
- 113: Make sure that the project is properly closed, either when project delivery is complete or when the project is terminated.
- 114: Obtain acceptance of deliverables and final sign-off that the project has been completed.
- 115: Document the overall satisfaction with the project.
- 116: Work with the project team to capture relevant experience and lessons learned for the benefit of future projects.
- 117: Complete performance reviews for each team member, recognize efforts and accomplishments, and celebrate success.
- 118: Make sure that all invoices have been delivered and all payments have been made.
- 119: Update and archive project documentation and make sure that all close out conditions have been met.
